# CronogramaReferencia.E3.060605. v01

Schedule from MS Project, 2006-06-05 to 2006-06-23.
MZO INTERATIVA S/S LTDA

## Calendars

- Standard: Mon-Fri 08:00-12:00, 13:00-17:00; Sat-Sun off. Exceptions (off unless hours are given): 2006-06-15.

## Resources

| Resource |
| --- |
| Micheli |
| Marcelo |
| 0 |

## Schedule

| ID | WBS | Task | Duration | Start | Finish | Predecessors | Total slack | Work |
| --- | --- | --- | --- | --- | --- | --- | --- | --- |
| 1 | 1 | **Evento Eletrônico Express - E3** | 14d | 2006-06-05 08:00 | 2006-06-23 17:00 |  | 0d | 50h |
| 2 | 1.1 | **Inicialização** | 0.5d | 2006-06-05 08:00 | 2006-06-05 12:00 |  | 0d |  |
| 3 | 1.1.1 | Criar repositório | 4h | 2006-06-05 08:00 | 2006-06-05 12:00 |  | 0d |  |
| 4 | 1.1.2 | Executar script para criação de base de dados | 1h | 2006-06-05 08:00 | 2006-06-05 09:00 |  | 0.38d |  |
| 5 | 1.1.3 | Configurar informações do evento | 1h | 2006-06-05 08:00 | 2006-06-05 09:00 |  | 0.38d |  |
| 6 | 1.2 | **Módulo de Inscrição** | 1d | 2006-06-05 13:00 | 2006-06-06 12:00 | 2 | 0d | 4h |
| 7 | 1.2.1 | **Configurar informações** | 0.5d | 2006-06-05 13:00 | 2006-06-05 17:00 |  | 0.5d |  |
| 8 | 1.2.1.1 | Cadastrar atividades | 4h | 2006-06-05 13:00 | 2006-06-05 17:00 |  | 0.5d |  |
| 9 | 1.2.1.2 | Configurar tipos de pagamento | 1h | 2006-06-05 13:00 | 2006-06-05 14:00 |  | 0.88d |  |
| 10 | 1.2.1.3 | Configurar ficha de dados pessoais | 1h | 2006-06-05 13:00 | 2006-06-05 14:00 |  | 0.88d |  |
| 11 | 1.2.1.4 | Configurar e-mail padrão | 0.5h | 2006-06-05 13:00 | 2006-06-05 13:30 |  | 0.94d |  |
| 12 | 1.2.1.5 | Configurar modelos de e-mail | 1h | 2006-06-05 13:00 | 2006-06-05 14:00 |  | 0.88d |  |
| 13 | 1.2.2 | Alterar CSS | 4h | 2006-06-05 13:00 | 2006-06-05 17:00 |  | 0.5d |  |
| 14 | 1.2.3 | Criar módulo do cartão de crédito para o evento | 2h | 2006-06-05 13:00 | 2006-06-05 15:00 |  | 0.75d |  |
| 15 | 1.2.4 | Testar inscrição | 8h | 2006-06-05 13:00 | 2006-06-06 12:00 |  | 0d | 4h |
| 16 | 1.2.5 | Ajustes | 8h | 2006-06-05 13:00 | 2006-06-06 12:00 |  | 0d |  |
| 17 | 1.3 | **Módulo de Submissão de trabalhos** | 1d | 2006-06-06 13:00 | 2006-06-07 12:00 | 6 | 0d | 4h |
| 18 | 1.3.1 | **Configurar informações** | 0.25d | 2006-06-06 13:00 | 2006-06-06 15:00 |  | 0.75d |  |
| 19 | 1.3.1.1 | Configurar e-mail padrão | 0.5h | 2006-06-06 13:00 | 2006-06-06 13:30 |  | 0.94d |  |
| 20 | 1.3.1.2 | Configurar modelos de e-mail | 2h | 2006-06-06 13:00 | 2006-06-06 15:00 |  | 0.75d |  |
| 21 | 1.3.1.3 | Configurar formatos de arquivos aceitos | 0.5h | 2006-06-06 13:00 | 2006-06-06 13:30 |  | 0.94d |  |
| 22 | 1.3.1.4 | Configurar fases de submissão | 0.5h | 2006-06-06 13:00 | 2006-06-06 13:30 |  | 0.94d |  |
| 23 | 1.3.2 | Alterar CSS | 4h | 2006-06-06 13:00 | 2006-06-06 17:00 |  | 0.5d |  |
| 24 | 1.3.3 | Testar envio de trabalhos | 8h | 2006-06-06 13:00 | 2006-06-07 12:00 |  | 0d | 4h |
| 25 | 1.3.4 | Ajustes | 8h | 2006-06-06 13:00 | 2006-06-07 12:00 |  | 0d |  |

Notes:
- 5: Informar os dados do evento na área administrativa: / - nome do evento / - local / - endereço / - data / - horário / - telefone / - fax / - site / - e-mail oficial
- 8: Informar os dados das atividades na área administrativa: / - Palestrantes / - Salas / - Áreas / - Tipos / - Valor padrão das atividades / - Atividades
- 9: Informar os tipos de pagamentos que ficarão disponíveis na inscrição pela área administrativa: / - boleto bancário (banco, agência, número da conta, ...) / - depósito bancário (banco, agência, número da conta, ...) / - cartão de crédito / - empenho
- 10: Informar quais campos da ficha de dados pessoais ficarão visíveis ou serão obrigatórios pela área administrativa.
- 11: Configurar e-mails que receberão cópia de todas as mensagens disparadas pela inscrição, além de configurar o e-mail utilizado como FROM das mensagens disparadas.
- 12: 4 ou 5 modelos
- 13: Alterar fontes, cores de fontes, estilos de botões, etc. / CSS = Cascade Style Sheet
- 14: Configurar diretório que conterá as transações efetuadas do evento.
- 19: Configurar e-mails que receberão cópia de todas as mensagens disparadas pela submissão de trabalhos, além de configurar o e-mail utilizado como FROM das mensagens disparadas.
- 20: +- de 15 a 20 modelos
- 21: Escolher pela área da administração quais formatos de arquivos serão aceitos no evento: / . pdf / . doc, etc
- 22: Configurar visibilidade do campo para fazer upload do trabalho (se no início do evento ou em uma fase posterior aos envios dos resumos).
- 23: Alterar fontes, cores de fontes, estilos de botões, etc. / CSS = Cascade Style Sheet

| ID | WBS | Task | Type | Duration | Start | Finish | Predecessors | Total slack | Constraint | Resources | Work |
| --- | --- | --- | --- | --- | --- | --- | --- | --- | --- | --- | --- |
| 26 | 1.4 | **Layout** |  | 4d | 2006-06-07 13:00 | 2006-06-13 12:00 | 17 | 0d |  |  |  |
| 27 | 1.4.1 | Criação do layout |  | 32h | 2006-06-07 13:00 | 2006-06-13 12:00 |  | 0d |  |  |  |
| 28 | 1.4.2 | Implementação do layout |  | 8h | 2006-06-07 13:00 | 2006-06-08 12:00 |  | 3d |  |  |  |
| 29 | 1.5 | **Publicador** |  | 0.25d | 2006-06-13 13:00 | 2006-06-13 15:00 | 26 | 0d |  |  |  |
| 30 | 1.5.1 | Configurar e-mail padrão do FALE CONOSCO |  | 0.5h | 2006-06-13 13:00 | 2006-06-13 13:30 |  | 0.19d |  |  |  |
| 31 | 1.5.2 | Configurar menu e sub-menu |  | 2h | 2006-06-13 13:00 | 2006-06-13 15:00 |  | 0d |  |  |  |
| 32 | 1.5.3 | Testar publicador |  | 2h | 2006-06-13 13:00 | 2006-06-13 15:00 |  | 0d |  |  |  |
| 33 | 1.6 | **Preparação da Entrega** |  | 1d | 2006-06-13 15:00 | 2006-06-14 15:00 | 29 | 0d |  |  |  |
| 34 | 1.6.1 | Teste de integração |  | 8h | 2006-06-13 15:00 | 2006-06-14 15:00 |  | 0d |  |  |  |
| 35 | 1.6.2 | Ajustes |  | 8h | 2006-06-13 15:00 | 2006-06-14 15:00 |  | 0d |  |  |  |
| 36 | 1.6.3 | **Preparação do Treinamento** |  | 0d | 2006-06-13 15:00 | 2006-06-13 15:00 |  | 1d |  |  |  |
| 37 | 1.6.3.1 | Inscrição | milestone | 0h | 2006-06-13 15:00 | 2006-06-13 15:00 |  | 1d |  |  |  |
| 38 | 1.6.3.2 | Submissão de Trabalhos | milestone | 0h | 2006-06-13 15:00 | 2006-06-13 15:00 |  | 1d |  |  |  |
| 39 | 1.6.3.3 | Publicador | milestone | 0h | 2006-06-13 15:00 | 2006-06-13 15:00 |  | 1d |  | 0 |  |
| 40 | 1.7 | **Entrega** |  | 2d | 2006-06-14 15:00 | 2006-06-19 15:00 | 33 | 0d |  |  | 8h |
| 41 | 1.7.1 | Executar script para criação de BD no servidor final |  | 1h | 2006-06-14 15:00 | 2006-06-14 16:00 |  | 1.88d |  |  |  |
| 42 | 1.7.2 | Alterar o config a partir do usuário e senha da BD no servidor final |  | 0.5h | 2006-06-14 15:00 | 2006-06-14 15:30 |  | 1.94d |  |  |  |
| 43 | 1.7.3 | Publicar o sistema no servidor final |  | 2h | 2006-06-14 15:00 | 2006-06-14 17:00 |  | 1.75d | start no earlier than 2006-06-05 08:00 |  |  |
| 44 | 1.7.4 | Treinar usuários |  | 16h | 2006-06-14 15:00 | 2006-06-19 15:00 |  | 0d |  |  | 8h |
| 45 | 1.7.5 | Teste de aceitação (cliente) | milestone | 0h | 2006-06-14 15:00 | 2006-06-14 15:00 |  | 2d |  |  |  |
| 46 | 1.7.6 | Ajustes |  | 16h | 2006-06-14 15:00 | 2006-06-19 15:00 |  | 0d |  |  |  |
| 47 | 1.8 | Manutenção |  | 8h | 2006-06-19 15:00 | 2006-06-20 15:00 | 40 | 0d |  |  | 8h |
| 48 | 1.9 | Acompanhamento de projetos |  | 8h | 2006-06-20 15:00 | 2006-06-21 15:00 | 47 | 0d |  |  | 8h |
| 49 | 1.10 | Colchão |  | 18h | 2006-06-21 15:00 | 2006-06-23 17:00 | 48 | 0d |  |  | 18h |

Notes:
- 30: Configurar e-mail que irá receber as dúvidas ou sugestões dos usuários.
- 31: Criar botões que ficarão disponíveis na barra lateral esquerda do site. Por meio da ativação desses botões, todas as ações são executadas (por exemplo: inscrição, submissão de trabalhos).
- 44: Considerando treinamento dos módulos inscrição, submissão de trabalho e publicador.
- 45: 40 horas de aceitação com cliente
